# My house building project

Schedule from GanttProject, 2006-01-09 to 2006-06-01.
Myself LLC

## Calendars

- Project calendar: Mon-Fri working; Sat-Sun off. Exceptions (off unless hours are given): 2006-02-14.

## Resources

| Resource | Group |
| --- | --- |
| Jack House |  |
| John Black | Excavator operator |
| Michelangelo | Architect |
| Tom White | Bricklayer |
| Peter Green | Bricklayer |
| George Brown | Bricklayer |
| John Silver | Foreman |

## Schedule

| ID | WBS | Task | Type | Duration | Start | Finish | Predecessors | Complete | Resources |
| --- | --- | --- | --- | --- | --- | --- | --- | --- | --- |
| 1 | 1 | **Architectural design** |  | 26d | 2006-01-09 | 2006-02-13 |  | 75% |  |
| 2 | 1.1 | Create draft of architecture |  | 10d | 2006-01-09 | 2006-01-20 |  | 100% | Michelangelo; Jack House [50%] |
| 3 | 1.2 | Prepare construction documents |  | 15d | 2006-01-23 | 2006-02-10 | 2 | 65% | Michelangelo |
| 4 | 1.3 | Agreement on architectural plan | milestone | 0d | 2006-02-13 | 2006-02-13 | 3 |  |  |
| 5 | 2 | **Interior design** |  | 10d | 2006-01-23 | 2006-02-03 |  | 33% |  |
| 6 | 2.1 | Pre-design |  | 5d | 2006-01-23 | 2006-01-27 | 2 | 100% | Michelangelo [50%]; Jack House |
| 7 | 2.2 | Furniture selection |  | 5d | 2006-01-30 | 2006-02-03 | 6 |  | Jack House |
| 8 | 2.3 | Equipment planning |  | 5d | 2006-01-30 | 2006-02-03 | 6 |  | Michelangelo [50%]; Jack House [50%] |
| 9 | 3 | **Construction phase** |  | 76d | 2006-02-15 | 2006-05-31 |  |  |  |
| 10 | 3.1 | Foundation building |  | 15d | 2006-02-15 | 2006-03-07 | 4 |  | George Brown; Tom White; John Silver; John Black |
| 11 | 3.2 | Ground Floor building |  | 20d | 2006-03-08 | 2006-04-04 | 10 |  | Peter Green; George Brown; Tom White; John Silver |
| 12 | 3.3 | First Floor building |  | 20d | 2006-04-05 | 2006-05-02 | 11 |  | Peter Green; George Brown; Tom White; John Silver |
| 13 | 3.4 | Roof |  | 10d | 2006-05-03 | 2006-05-16 | 12 |  | Tom White; John Silver |
| 14 | 3.5 | Connect to communications |  | 10d | 2006-05-18 | 2006-05-31 | 15 |  | Peter Green; John Black |
| 15 | 3.6 | Construction completed | milestone | 0d | 2006-05-17 | 2006-05-17 | 13 |  |  |
| 16 | 4 | **Decoration phase** |  | 11d | 2006-05-18 | 2006-06-01 |  |  |  |
| 17 | 4.1 | Walls |  | 5d | 2006-05-18 | 2006-05-24 | 5, 15 |  | Peter Green; George Brown; Tom White; John Silver |
| 18 | 4.2 | Furniture |  | 3d | 2006-05-25 | 2006-05-29 | 17 |  | Tom White; Jack House |
| 19 | 4.3 | Bring your family here | milestone | 0d | 2006-06-01 | 2006-06-01 | 9, 18 |  |  |

Notes:
- 8: Embedded devices, kitchen, washing machine, dryer etc
